# Cronograma fisico_Manutenção de Coberturas de Madeira - PE Juquery

Schedule from MS Project, 2022-03-01 to 2022-06-02.

## Calendars

- Padrão: Mon-Fri 09:00-12:00, 13:00-18:00; Sat-Sun off.

## Resources

| Resource |
| --- |
| 13 |

## Schedule

| ID | WBS | Task | Duration | Start | Finish | Predecessors | Total slack | Free slack | Constraint |
| --- | --- | --- | --- | --- | --- | --- | --- | --- | --- |
| 1 | 1 | **MANUTENÇÃO DAS COBERTURAS DE MADEIRA DO PARQUE ESTADUAL DO JUQUERY** | 68d | 2022-03-01 | 2022-06-02 |  | 0d |  |  |
| 2 | 1.1 | Ordem de inicio de serviços | 1d | 2022-03-01 | 2022-03-01 |  | 6d | 0d | start no earlier than 2022-03-01 |
| 3 | 1.2 | Placa de identificação para obra | 7d | 2022-03-02 | 2022-03-10 | 2 | 60d |  |  |
| 4 | 1.3 | **GALPÃO 01** | 28d | 2022-03-09 | 2022-04-15 |  | 6d |  |  |
| 5 | 1.3.1 | Retirada de telhamento em barro, cumeeira, agua furtada, forros de madeira e trama de madeira | 5d | 2022-03-09 | 2022-03-15 | 2FS+5d | 6d | 0d |  |
| 6 | 1.3.2 | Execução de trama de madeira | 8d | 2022-03-16 | 2022-03-25 | 5 | 6d | 0d |  |
| 7 | 1.3.3 | Instalação de telha de barro tipo italiana | 7d | 2022-03-28 | 2022-04-05 | 6 | 6d | 0d |  |
| 8 | 1.3.4 | Execução de Cumeeira | 3d | 2022-04-06 | 2022-04-08 | 7 | 6d | 0d |  |
| 9 | 1.3.5 | Instalação de agua furtada | 2d | 2022-04-11 | 2022-04-12 | 8 | 6d | 0d |  |
| 10 | 1.3.6 | Imunizante para madeira | 3d | 2022-04-13 | 2022-04-15 | 9 | 6d | 0d |  |
| 11 | 1.4 | **GALPÃO 02** | 28d | 2022-04-18 | 2022-05-25 |  | 6d |  |  |
| 12 | 1.4.1 | Retirada de telhamento em barro, cumeeira, agua furtada, forros de madeira e trama de madeira | 5d | 2022-04-18 | 2022-04-22 | 10 | 6d | 0d |  |
| 13 | 1.4.2 | Execução de trama de madeira | 8d | 2022-04-25 | 2022-05-04 | 12 | 6d | 0d |  |
| 14 | 1.4.3 | Instalação de telha de barro tipo italiana | 7d | 2022-05-05 | 2022-05-13 | 13 | 6d | 0d |  |
| 15 | 1.4.4 | Execução de Cumeeira | 3d | 2022-05-16 | 2022-05-18 | 14 | 6d | 0d |  |
| 16 | 1.4.5 | Instalação de agua furtada | 2d | 2022-05-19 | 2022-05-20 | 15 | 6d | 0d |  |
| 17 | 1.4.6 | Imunizante para madeira | 3d | 2022-05-23 | 2022-05-25 | 16 | 6d |  |  |
| 18 | 1.5 | **ALOJAMENTO** | 2d | 2022-05-24 | 2022-05-25 |  | 0d |  |  |
| 19 | 1.5.1 | Recolocação de telhas de barro tipo francesa | 2d | 2022-05-24 | 2022-05-25 |  | 0d |  | start no earlier than 2022-05-24 |
| 20 | 1.6 | **VIGILANCIA** | 2d | 2022-05-26 | 2022-05-27 |  | 0d |  |  |
| 21 | 1.6.1 | Recolocação de telhas de barro tipo francesa | 2d | 2022-05-26 | 2022-05-27 | 19 | 0d |  |  |
| 22 | 1.7 | **EDUCAÇÃO AMBIENTAL** | 3d | 2022-05-30 | 2022-06-01 |  | 0d |  |  |
| 23 | 1.7.1 | Recolocação de telhas de barro tipo francesa | 2d | 2022-05-30 | 2022-05-31 | 21 | 0d |  |  |
| 24 | 1.7.2 | Demolição manual de forro em estuque, inclusive sistema de fixação/tarugamento | 1d | 2022-06-01 | 2022-06-01 | 23 | 0d |  |  |

| ID | WBS | Task | Type | Duration | Start | Finish | Predecessors | Total slack |
| --- | --- | --- | --- | --- | --- | --- | --- | --- |
| 25 | 1.8 | **SEDE** |  | 1d | 2022-06-02 | 2022-06-02 |  | 0d |
| 26 | 1.8.1 | Recolocação de telhas de barro tipo francesa |  | 1d | 2022-06-02 | 2022-06-02 | 24 | 0d |
| 27 | 1.8.2 | Termino da obra (Emissão do TRP - Termo de Recebimento Provisório) | milestone | 0d | 2022-06-02 | 2022-06-02 | 26, 17 | 0d |
